# NZTH Project Schedule2

Schedule from MS Project, 2015-08-31 to 2016-09-14, A marks actual dates.

## Calendars

- Standard: Mon-Fri 08:00-12:00, 13:00-17:00; Sat 08:00-16:00; Sun off. Exceptions (off unless hours are given): 2015-11-14 08:00-12:00, 13:00-17:00, 2015-11-21 08:00-12:00, 13:00-17:00, 2015-11-26 to 2015-11-27 (Thanksgiving), 2015-11-28 08:00-12:00, 13:00-17:00, 2015-12-05 08:00-12:00, 13:00-17:00, 2015-12-23 to 2015-12-26 (Christmas), 2016-02-06 08:00-12:00, 13:00-17:00, 2016-02-13 08:00-12:00, 13:00-17:00, 2016-02-20 08:00-12:00, 13:00-17:00, 2016-02-27 08:00-12:00, 13:00-17:00, 2016-03-12 08:00-12:00, 13:00-17:00, 2016-03-26 08:00-12:00, 13:00-17:00, 2016-04-09 08:00-12:00, 13:00-17:00, 2016-04-16 08:00-12:00, 13:00-17:00, 2016-04-23 08:00-12:00, 13:00-17:00.

## Resources

| Resource |
| --- |
| Concrete contractor |
| Finish carpentry contractor |
| Fencing contractor |
| Masonry contractor |
| General contractor |
| Architect |
| Owner |
| Mortgage lender |
| Inspector |
| Electric company |
| Site excavation contractor |
| Electric contractor |
| Plumbing contractor |
| Framing contractor |
| Roofing contractor |
| Heating and AC contractor |
| Insulation contractor |
| Drywall contractor |
| Painting contractor |
| Flooring contractor |
| Appliance contractor |
| Landscape contractor |
| Maid service |
| Design Team |
| MFET Team |
| Excavator |
| Framing wood |
| Sheathing |
| Concrete |
| Fiber cement siding |
| Roofing |
| Insulation |
| Windows |
| Solar panels |
| Exterior door |
| Drywall |
| Paint |
| Stain |
| Wood flooring |
| Forest Allen |
| Alexis Sheffield |
| Jason Sylvester |
| Ben Bartholomew |
| Dewey Lakey |
| Burt Scofield |
| Alex Shreyer |

## Schedule

| ID | WBS | Task | Type | Duration | Start | Finish | Predecessors | Complete | Remaining | Actual start | Actual finish | Baseline start | Baseline finish | Baseline duration | Total slack | Free slack | Constraint | Resources | Work | Actual work |
| --- | --- | --- | --- | --- | --- | --- | --- | --- | --- | --- | --- | --- | --- | --- | --- | --- | --- | --- | --- | --- |
| 1 | 1 | **Net-Zero Tiny House** |  | 203d | 2015-08-31 | 2016-04-29 |  | 48% | 104.91d | 2015-09-26 |  | 2015-08-31 | 2021-04-02 | 1751d? |  |  |  |  | 944h | 723.2h |
| 2 | 1.1 | **Design Work** |  | 21d | 2015-09-26 A | 2015-10-20 |  | 97% | 0.64d |  |  | 2015-09-26 | 2015-10-28 | 28d? |  |  |  |  | 552h | 535.2h |
| 3 | 1.1.1 | Have first revision house design done |  | 21d | 2015-09-26 A | 2015-10-20 A |  | 100% |  |  |  | 2015-09-26 | 2015-10-20 | 21d? |  |  | finish no earlier than 2015-10-20 | Design Team | 168h | 168h |
| 4 | 1.1.2 | Have first revision rocket stove design done |  | 6d? | 2015-10-14 A | 2015-10-20 A |  | 100% |  |  |  | 2015-10-14 | 2015-10-20 | 6d? |  |  | finish no earlier than 2015-10-20 | MFET Team | 48h | 48h |
| 5 | 1.1.3 | Have house design done |  | 42d | 2015-10-21 A | 2015-12-10 |  | 95% | 2.1d |  |  | 2015-10-21 | 2015-10-28 | 7d | 235d |  | finish no earlier than 2015-12-10 | Design Team | 336h | 319.2h |
| 6 | 1.2 | **Apply for Permits** |  | 21d | 2015-11-18 | 2015-12-14 |  |  |  |  |  | 2015-11-04 | 2015-11-27 | 21d | 65d |  |  |  |  |  |
| 7 | 1.2.1 | Send plans in for permit |  | 21d | 2015-11-18 | 2015-12-14 |  |  |  |  |  | 2015-11-04 | 2015-11-27 | 21d | 23d | 0d | start no earlier than 2015-11-18 |  |  |  |
| 8 | 1.2.2 | Obtain permit | milestone | 0d | 2015-12-14 | 2015-12-14 | 7 |  |  |  |  |  |  |  | 23d |  |  |  |  |  |
| 9 | 1.3 | **Site Work** |  | 1d | 2015-11-13 A | 2015-11-13 A |  | 100% |  |  |  | 2015-11-13 | 2015-11-13 | 1d |  |  |  |  |  |  |
| 10 | 1.3.1 | Clear shed |  | 1d | 2015-11-13 A | 2015-11-13 A |  | 100% |  |  |  | 2015-11-13 | 2015-11-13 | 1d |  |  | start no earlier than 2015-11-13 |  |  |  |
| 11 | 1.4 | **Bill of Materials and Estimate** |  | 23d | 2015-11-02 A | 2015-11-30 |  | 100% |  |  | 2015-12-09 |  |  |  |  |  |  |  | 184h | 184h |
| 12 | 1.4.1 | Compile data for BoM and estimate |  | 23d | 2015-11-02 A | 2015-11-30 A |  | 100% |  |  |  |  |  |  |  |  | finish no earlier than 2015-11-30 | Forest Allen | 184h | 184h |
| 13 | 1.4.2 | Complete draft of BoM |  | 31d | 2015-11-02 A | 2015-12-09 A | 12 | 100% |  |  |  |  |  |  |  |  | finish no earlier than 2015-12-09 |  |  |  |
| 14 | 1.5 | **Documentation and Presentation** |  | 14d | 2015-11-24 A | 2015-12-11 A |  | 100% |  |  |  |  |  |  |  |  |  |  |  |  |
| 15 | 1.5.1 | Create project PowerPoint |  | 14d | 2015-11-24 A | 2015-12-11 A |  | 100% |  |  |  |  |  |  |  |  |  |  |  |  |
| 16 | 1.5.2 | Present to faculty |  | 1d | 2015-11-24 A | 2015-11-24 A |  | 100% |  |  |  |  |  |  |  |  |  |  |  |  |
| 17 | 1.5.3 | Presentation complete | milestone | 0d | 2015-12-11 A | 2015-12-11 A | 15, 16 | 100% |  |  |  |  |  |  |  |  | start no earlier than 2015-12-11 |  |  |  |
| 18 | 1.6 | **Foundation** |  | 20d | 2016-03-04 | 2016-03-26 |  | 7% | 18.61d | 2015-10-14 |  | 2015-11-20 | 2015-12-24 | 30d? |  |  |  |  | 208h | 4h |
| 19 | 1.6.1 | Trenching for water and electrical |  | 2d | 2016-03-04 | 2016-03-05 | 8 |  |  |  |  | 2015-11-20 | 2015-11-21 | 2d | 0d |  | start no earlier than 2016-03-04 | Excavator [0.1%] |  |  |
| 20 | 1.6.2 | Excavate for foundations |  | 2d | 2016-03-04 | 2016-03-05 | 10, 8 |  |  |  |  | 2015-11-20 | 2015-11-21 | 2d | 0d |  | start no earlier than 2016-03-04 | Excavator [0.1%] |  |  |
| 21 | 1.6.3 | Install temporary power service |  | 1d | 2016-03-04 | 2016-03-04 | 10, 8 |  |  |  |  | 2015-11-20 | 2015-11-20 | 1d? | 1d |  | start no earlier than 2016-03-04 |  |  |  |
| 22 | 1.6.4 | Install underground utilities |  | 2d | 2016-03-04 | 2016-03-05 | 10, 8 |  |  |  |  | 2015-11-20 | 2015-11-21 | 2d? | 0d |  | start no earlier than 2016-03-04 |  |  |  |
| 23 | 1.6.5 | Form footings |  | 2d | 2016-03-07 | 2016-03-08 | 19, 20, 21, 22 |  |  |  |  | 2015-11-23 | 2015-11-24 | 2d | 0d |  | start no earlier than 2015-11-23 |  |  |  |
| 24 | 1.6.6 | Footings Inspection |  | 1d | 2016-03-09 | 2016-03-09 | 23 |  |  |  |  | 2015-11-25 | 2015-11-25 | 1d? | 0d |  | start no earlier than 2015-11-25 | Inspector | 8h |  |
| 25 | 1.6.7 | Pour Footings |  | 1d | 2016-03-10 | 2016-03-10 | 24 |  |  |  |  | 2015-11-26 | 2015-11-26 | 1d | 0d |  | start no earlier than 2015-11-19 | Concrete |  |  |
| 26 | 1.6.8 | Form Stem Walls |  | 3d | 2016-03-11 | 2016-03-14 | 25 |  |  |  |  | 2015-11-27 | 2015-11-30 | 3d | 0d |  | start no earlier than 2015-11-21 |  |  |  |
| 27 | 1.6.9 | Stem Wall Inspection |  | 1d | 2016-03-15 | 2016-03-15 | 26 |  |  |  |  | 2015-12-02 | 2015-12-02 | 1d? | 0d |  | start no earlier than 2015-12-02 | Inspector | 8h |  |
| 28 | 1.6.10 | Pour stem walls |  | 1d | 2016-03-16 | 2016-03-16 | 27 |  |  |  |  | 2015-12-04 | 2015-12-04 | 1d | 0d |  | start no earlier than 2015-12-04 | Concrete |  |  |
| 29 | 1.6.11 | Put in under floor plumbing |  | 2d | 2016-03-11 | 2016-03-12 | 25 |  |  |  |  | 2015-12-04 | 2015-12-05 | 2d | 3d | 0d | start no earlier than 2015-12-04 |  |  |  |
| 30 | 1.6.12 | Insulate floor |  | 1d | 2016-03-14 | 2016-03-14 | 29 |  |  |  |  | 2015-12-07 | 2015-12-07 | 1d | 3d |  | start no earlier than 2015-12-05 | Insulation |  |  |
| 31 | 1.6.13 | Strip Wall Forms |  | 1d | 2016-03-17 | 2016-03-17 | 28 |  |  |  |  | 2015-12-07 | 2015-12-07 | 1d? | 0d |  | start no earlier than 2015-12-07 |  |  |  |
| 32 | 1.6.14 | Pour floor |  | 1d | 2016-03-18 | 2016-03-18 | 31, 30 |  |  |  |  | 2015-12-16 | 2015-12-16 | 1d? | 0d |  | start no earlier than 2015-12-16 | Concrete |  |  |
| 33 | 1.6.15 | Cure Time |  | 6d | 2016-03-19 | 2016-03-25 | 32 |  |  |  |  | 2015-12-17 | 2015-12-23 | 6d? | 0d |  | finish no earlier than 2015-12-23 |  |  |  |
| 34 | 1.6.16 | Weather proof foundation |  | 1d | 2016-03-26 | 2016-03-26 | 33 |  |  |  |  | 2015-12-24 | 2015-12-24 | 1d? | 0d |  |  |  |  |  |
| 35 | 1.6.17 | Foundation work complete | milestone | 0d | 2016-02-06 | 2016-02-06 |  |  |  |  |  | 2015-12-24 | 2015-12-24 |  | 173d | 0d | start no earlier than 2016-02-06 |  |  |  |

| ID | WBS | Task | Type | Duration | Start | Finish | Predecessors | Complete | Remaining | Baseline start | Baseline finish | Baseline duration | Total slack | Free slack | Constraint | Resources | Work | Actual work |
| --- | --- | --- | --- | --- | --- | --- | --- | --- | --- | --- | --- | --- | --- | --- | --- | --- | --- | --- |
| 36 | 1.6.18 | **Rocket Stove Manufacture** |  | 39d | 2016-01-11 A | 2016-02-24 |  | 3% | 37.97d | 2015-12-14 | 2016-02-01 | 43d |  |  |  |  | 152h | 4h |
| 37 | 1.6.18.1 | Rocket Stove Manufacture |  | 19d | 2016-01-11 A | 2016-02-01 |  | 3% | 18.5d | 2016-01-11 | 2016-02-01 | 19d? | 194d |  | start no earlier than 2016-01-11 | MFET Team | 152h | 4h |
| 38 | 1.6.18.2 | Rocket Stove Complete | milestone | 0d | 2016-02-01 | 2016-02-01 |  |  |  | 2015-12-14 | 2015-12-14 |  | 195d |  | start no earlier than 2016-02-01 |  |  |  |
| 39 | 1.6.19 | **Framing** |  | 20d | 2016-01-29 A | 2016-02-20 |  | 63% | 7.33d | 2016-02-05 | 2016-02-27 | 20d? |  |  |  |  |  |  |
| 40 | 1.6.19.1 | Frame First Floor walls |  | 1d | 2016-01-29 A | 2016-01-29 A |  | 100% |  | 2016-02-05 | 2016-02-05 | 1d? |  |  | start no earlier than 2016-01-29 | Framing wood |  |  |
| 41 | 1.6.19.2 | Install floor joists and gluelam beam |  | 1d | 2016-02-05 A | 2016-02-05 A | 40 | 100% |  | 2016-02-06 | 2016-02-08 | 2d |  |  | finish no earlier than 2016-02-05 | Framing wood |  |  |
| 42 | 1.6.19.3 | Lay floor decking |  | 1d | 2016-02-12 | 2016-02-12 | 41 |  |  | 2016-02-10 | 2016-02-10 | 1d | 184d |  | finish no earlier than 2016-02-12 | Framing wood |  |  |
| 43 | 1.6.19.4 | Frame 2nd floor walls |  | 7d | 2016-02-05 A | 2016-02-12 A |  | 100% |  | 2016-02-12 | 2016-02-13 | 2d |  |  | finish no earlier than 2016-02-12 | Framing wood |  |  |
| 44 | 1.6.19.5 | Frame roof trusses |  | 1d | 2016-02-17 | 2016-02-17 | 43 |  |  | 2016-02-17 | 2016-02-17 | 1d? | 1.5d | 1d | finish no earlier than 2016-02-17 | Framing wood |  |  |
| 45 | 1.6.19.6 | Frame end walls |  | 1d | 2016-02-19 A | 2016-02-19 | 44 | 50% | 0.5d | 2016-02-19 | 2016-02-19 | 1d? | 169d | 0d | finish no earlier than 2016-02-19 | Framing wood |  |  |
| 46 | 1.6.19.7 | Frame dormer and put sheathing on roof |  | 1d | 2016-02-19 | 2016-02-20 | 45 |  |  | 2016-02-20 | 2016-02-20 | 1d? | 169d | 4d | finish no earlier than 2016-02-20 | Framing wood; Sheathing |  |  |
| 47 | 1.6.19.8 | Frame roofing |  | 1d | 2016-02-26 | 2016-02-26 | 46 |  |  | 2016-02-26 | 2016-02-26 | 1d? | 165d | 0d | finish no earlier than 2016-02-26 | Framing wood |  |  |
| 48 | 1.6.19.9 | Frame windows |  | 1d | 2016-02-27 | 2016-02-27 | 47 |  |  | 2016-02-27 | 2016-02-27 | 1d? | 165d | 0d | finish no earlier than 2016-02-27 | Framing wood |  |  |
| 49 | 1.6.19.10 | Framing complete | milestone | 0d | 2016-02-27 | 2016-02-27 | 48 |  |  | 2016-02-27 | 2016-02-27 |  | 165d | 3d | start no earlier than 2016-02-27 |  |  |  |
| 50 | 1.6.20 | **Dry In and Stairs** |  | 15d | 2016-03-03 | 2016-03-19 |  |  |  | 2016-03-03 | 2016-03-19 | 15d? |  |  |  |  |  |  |
| 51 | 1.6.20.1 | Sheath exterior walls |  | 2d | 2016-03-03 | 2016-03-04 | 49 |  |  | 2016-03-03 | 2016-03-04 | 2d | 162d | 4d | finish no earlier than 2016-03-04 | Sheathing |  |  |
| 52 | 1.6.20.2 | Soffit and fascia |  | 2d | 2016-03-03 | 2016-03-04 | 47 |  |  | 2016-03-03 | 2016-03-04 | 2d | 162d | 1d | finish no earlier than 2016-03-04 |  |  |  |
| 53 | 1.6.20.3 | Finish roofing |  | 3d | 2016-03-07 | 2016-03-09 | 52 |  |  | 2016-03-07 | 2016-03-09 | 3d | 161d | 5d | finish no earlier than 2016-03-09 | Roofing |  |  |
| 54 | 1.6.20.4 | Finish window install |  | 2d | 2016-03-10 | 2016-03-11 | 51 |  |  | 2016-03-10 | 2016-03-11 | 2d | 160d |  | finish no earlier than 2016-03-11 | Windows |  |  |
| 55 | 1.6.20.5 | Install solar roof panels |  | 1d | 2016-03-16 | 2016-03-16 | 53 |  |  | 2016-03-16 | 2016-03-16 | 1d? | 156d |  | finish no earlier than 2016-03-16 | Solar panels |  |  |
| 56 | 1.6.20.6 | Hang exterior door |  | 1d | 2016-03-16 | 2016-03-16 | 51 |  |  | 2016-03-16 | 2016-03-16 | 1d | 153d | 0d | finish no earlier than 2016-03-16 | Exterior door |  |  |
| 57 | 1.6.20.7 | Install house wrap |  | 3d | 2016-03-17 | 2016-03-19 | 56 |  |  | 2016-03-17 | 2016-03-19 | 3d | 153d |  | finish no earlier than 2016-03-16 |  |  |  |
| 58 | 1.6.20.8 | Frame stairs |  | 1d | 2016-03-18 | 2016-03-18 | 51 |  |  | 2016-03-18 | 2016-03-18 | 1d? | 154d |  | finish no earlier than 2016-03-18 | Framing wood |  |  |
| 59 | 1.6.20.9 | Dry-in complete | milestone | 0d | 2016-03-18 | 2016-03-18 |  |  |  | 2016-03-18 | 2016-03-18 |  | -44d | 0d | start no earlier than 2016-03-18 |  |  |  |

| ID | WBS | Task | Type | Duration | Start | Finish | Predecessors | Baseline start | Baseline finish | Baseline duration | Total slack | Free slack | Constraint | Resources | Work |
| --- | --- | --- | --- | --- | --- | --- | --- | --- | --- | --- | --- | --- | --- | --- | --- |
| 60 | 1.6.21 | **Exterior Finishes** |  | 10d | 2016-03-18 | 2016-03-29 |  | 2015-08-31 | 2016-03-29 | 182d | -44d | 0d |  |  |  |
| 61 | 1.6.21.1 | Complete exterior finish |  | 10d | 2016-03-18 | 2016-03-29 | 59 | 2016-03-18 | 2016-03-29 | 10d | -44d | 0d | finish no earlier than 2016-03-23 | Fiber cement siding |  |
| 62 | 1.6.21.2 | Exterior finish complete | milestone | 0d | 2016-03-29 | 2016-03-29 |  | 2015-08-31 | 2015-08-31 |  | -46d | 0d | finish no earlier than 2016-03-29 |  |  |
| 63 | 1.6.22 | **Utility Rough-B97Ins and Complete Concrete** |  | 124d | 2015-10-14 | 2016-03-12 |  | 2015-10-14 | 2016-03-12 | 130d |  |  |  |  | 16h |
| 64 | 1.6.22.1 | Rough-in plumbing |  | 2d | 2016-03-18 | 2016-03-19 | 59 | 2016-03-18 | 2016-03-19 | 2d | 152d | 3d | finish no earlier than 2016-03-12 |  |  |
| 65 | 1.6.22.2 | Rough-in electrical |  | 5d | 2016-03-18 | 2016-03-23 | 59 | 2016-03-18 | 2016-03-23 | 5d | 149d | 0d | finish no earlier than 2016-03-16 |  |  |
| 66 | 1.6.22.3 | Rough-in heating |  | 1d | 2016-03-18 | 2016-03-18 | 59 | 2016-03-18 | 2016-03-18 | 1d | 153d | 4d | finish no earlier than 2016-03-16 |  |  |
| 67 | 1.6.22.4 | Rough-in communication - phone, cable, computer, alarm |  | 2d | 2016-03-18 | 2016-03-19 | 59 | 2016-03-18 | 2016-03-19 | 2d | 152d | 3d | finish no earlier than 2016-03-18 |  |  |
| 68 | 1.6.22.5 | 4-Way Inspection |  | 1d? | 2016-03-24 | 2016-03-24 | 64, 65, 66, 67 | 2016-03-24 | 2016-03-24 | 1d? | 149d |  | finish no earlier than 2016-03-23 | General contractor; Inspector | 16h |
| 69 | 1.6.22.6 | Rough-in complete | milestone | 0d | 2015-10-14 | 2015-10-14 |  | 2015-10-14 | 2015-10-14 |  | 124d |  |  |  |  |
| 70 | 1.6.23 | **Interior Finishes** |  | 131d | 2015-10-14 | 2016-03-21 |  | 2015-10-14 | 2016-03-21 | 137d |  |  |  |  | 16h |
| 71 | 1.6.23.1 | **Insulation** |  | 1d | 2016-03-21 | 2016-03-21 |  | 2016-03-21 | 2016-03-21 | 1d |  |  |  |  | 16h |
| 72 | 1.6.23.1.1 | Place wall insulation - 1st floor |  | 1d | 2016-03-21 | 2016-03-21 | 69 | 2016-03-21 | 2016-03-21 | 1d | 7d | 3d | finish no earlier than 2016-03-21 | Insulation |  |
| 73 | 1.6.23.1.2 | Place wall insulation - 2nd floor |  | 1d | 2016-03-21 | 2016-03-21 | 69 | 2016-03-21 | 2016-03-21 | 1d | 7d | 3d | finish no earlier than 2016-03-21 | Insulation |  |
| 74 | 1.6.23.1.3 | Conduct insulation inspection |  | 1d | 2016-03-25 | 2016-03-25 | 72, 73 | 2016-03-25 | 2016-03-25 | 1d | 4d | 0d | finish no earlier than 2016-03-25 | Inspector; Insulation contractor | 16h |
| 75 | 1.6.23.2 | **Drywall** |  | 149d? | 2016-03-25 | 2016-09-14 |  | 2016-03-25 | 2016-09-14 | 149d? |  |  |  |  |  |
| 76 | 1.6.23.2.1 | Install drywall - 1st floor walls |  | 1d | 2016-03-26 | 2016-03-26 | 74 | 2016-03-26 | 2016-03-26 | 1d | 6d | 5d | finish no earlier than 2016-03-26 | Drywall |  |
| 77 | 1.6.23.2.2 | Install drywall - 1st floor overhead |  | 2d | 2016-03-26 | 2016-03-28 | 74 | 2016-03-26 | 2016-03-28 | 2d | 5d | 4d |  | Drywall |  |
| 78 | 1.6.23.2.3 | Install drywall 2nd floor walls |  | 3d | 2016-03-30 | 2016-04-01 | 74 | 2016-03-30 | 2016-04-01 | 3d | 1d | 0d | start no earlier than 2016-03-30 | Drywall |  |
| 79 | 1.6.23.2.4 | Install drywall 2nd floor overhead |  | 3d | 2016-03-30 | 2016-04-01 | 74 | 2016-03-30 | 2016-04-01 | 3d | 1d | 0d | start no earlier than 2016-03-30 | Drywall |  |
| 80 | 1.6.23.2.5 | Tape and float 1st coat drywall |  | 2d | 2016-04-02 | 2016-04-04 | 76, 77, 78, 79 | 2016-04-02 | 2016-04-04 | 2d | 1d |  | start no earlier than 2016-04-02 |  |  |
| 81 | 1.6.23.2.6 | Tape and float 2nd coat drywall |  | 2d | 2016-04-08 | 2016-04-09 | 80 | 2016-04-08 | 2016-04-09 | 2d | -2d | 0d | finish no earlier than 2016-04-09 |  |  |
| 82 | 1.6.23.2.7 | Place ceiling insulation - 2nd floor |  | 1d? | 2016-04-11 | 2016-04-11 | 81 | 2016-04-11 | 2016-04-11 | 1d? | 134d |  |  | Insulation |  |
| 83 | 1.6.23.2.8 | Cement board around rocket stove area |  | 1d | 2016-04-11 | 2016-04-11 | 81 | 2016-04-11 | 2016-04-11 | 1d | 134d |  | start no earlier than 2016-04-08 |  |  |
| 84 | 1.6.23.2.9 | Insulation and drywall complete | milestone | 0d | 2016-04-09 | 2016-04-09 | 81 | 2016-04-09 | 2016-04-09 |  | -2d | 0d |  |  |  |

| ID | WBS | Task | Type | Duration | Start | Finish | Predecessors | Baseline start | Baseline finish | Baseline duration | Total slack | Free slack | Constraint | Resources |
| --- | --- | --- | --- | --- | --- | --- | --- | --- | --- | --- | --- | --- | --- | --- |
| 85 | 1.6.23.3 | **Paint and Stain** |  | 151d | 2015-10-14 | 2016-04-13 |  | 2015-10-14 | 2016-04-13 | 157d |  |  |  |  |
| 86 | 1.6.23.3.1 | Texture first floor |  | 1d | 2016-04-13 | 2016-04-13 | 84 | 2016-04-13 | 2016-04-13 | 1d | -4d | 0d | start no earlier than 2016-04-13 |  |
| 87 | 1.6.23.3.2 | Texture second floor |  | 1d | 2016-04-13 | 2016-04-13 | 84 | 2016-04-13 | 2016-04-13 | 1d? | -4d | 0d | start no earlier than 2016-04-13 |  |
| 88 | 1.6.23.3.3 | Paint first floor |  | 2d | 2016-04-15 | 2016-04-16 | 86 | 2016-04-15 | 2016-04-16 | 2d | -5d | 0d | finish no earlier than 2016-04-16 | Paint |
| 89 | 1.6.23.3.4 | Paint second floor |  | 2d | 2016-04-15 | 2016-04-16 | 87 | 2016-04-15 | 2016-04-16 | 2d | -5d | 0d | start no earlier than 2016-04-15 | Paint |
| 90 | 1.6.23.3.5 | Prep floor for staining |  | 1d | 2016-04-18 | 2016-04-18 | 88, 89 | 2016-04-18 | 2016-04-18 | 1d? | -5d | 0d | start no earlier than 2016-04-18 |  |
| 91 | 1.6.23.3.6 | Stain concrete flooring |  | 1d | 2016-04-19 | 2016-04-19 | 90 | 2016-04-19 | 2016-04-19 | 1d? | -5d | 0d | start no earlier than 2016-04-19 | Stain |
| 92 | 1.6.23.3.7 | Painting and staining complete | milestone | 0d | 2016-04-19 | 2016-04-19 | 89, 91 | 2016-04-19 | 2016-04-19 |  | -5d | 0d |  |  |
| 93 | 1.6.23.4 | **Cabinets** |  | 2d | 2016-04-20 | 2016-04-21 |  | 2016-04-20 | 2016-04-21 | 2d? |  |  |  |  |
| 94 | 1.6.23.4.1 | Install cabinets - kitchen and bathroom, |  | 1d | 2016-04-20 | 2016-04-20 | 92 | 2016-04-20 | 2016-04-20 | 1d? | 1d |  |  |  |
| 95 | 1.6.23.4.2 | Install railings |  | 3d | 2016-04-20 | 2016-04-22 | 92 | 2016-04-20 | 2016-04-22 | 3d | -1d | 0d | start no earlier than 2016-04-20 |  |
| 96 | 1.6.23.4.3 | Cabinets and railings complete | milestone | 0d | 2016-04-22 | 2016-04-22 | 94, 95 | 2016-04-22 | 2016-04-22 |  | -1d | 0d |  |  |
| 97 | 1.6.23.5 | **Finish Plumbing** |  | 4d | 2016-04-22 | 2016-04-26 |  | 2016-04-22 | 2016-04-26 | 4d |  |  |  |  |
| 98 | 1.6.23.5.1 | Complete kitchen plumbing |  | 2d | 2016-04-23 | 2016-04-25 | 96 | 2016-04-23 | 2016-04-25 | 2d | 1d | 0d | finish no earlier than 2016-04-23 |  |
| 99 | 1.6.23.5.2 | Complete bathroom plumbing |  | 2d | 2016-04-23 | 2016-04-25 | 96 | 2016-04-23 | 2016-04-25 | 2d | 1d | 0d | start no earlier than 2016-04-22 |  |
| 100 | 1.6.23.5.3 | Plumbing complete | milestone | 0d | 2016-04-25 | 2016-04-25 | 98, 99 | 2016-04-25 | 2016-04-25 |  | 1d |  |  |  |
| 101 | 1.6.23.6 | **Finish Electrical** |  | 2d | 2016-04-22 | 2016-04-23 |  | 2016-04-22 | 2016-04-23 | 2d |  |  |  |  |
| 102 | 1.6.23.6.1 | Complete circuits to service panel |  | 2d | 2016-04-22 | 2016-04-23 | 92 | 2016-04-22 | 2016-04-23 | 2d | 0d |  |  |  |
| 103 | 1.6.23.6.2 | Complete communications wiring - phone, cable, computer, alarm |  | 2d | 2016-04-22 | 2016-04-23 | 92 | 2016-04-22 | 2016-04-23 | 2d | 0d |  |  |  |
| 104 | 1.6.23.6.3 | Electrical complete | milestone | 0d | 2016-04-23 | 2016-04-23 | 102, 103 | 2016-04-23 | 2016-04-23 |  | 0d |  |  |  |
| 105 | 1.6.23.7 | **Flooring and Appliances** |  | 3d | 2016-04-25 | 2016-04-27 |  | 2016-04-25 | 2016-04-27 | 3d |  |  |  |  |
| 106 | 1.6.23.7.1 | Install wood flooring upstairs |  | 1d | 2016-04-25 | 2016-04-25 | 96 | 2016-04-25 | 2016-04-25 | 1d | 2d | 1d |  | Wood flooring |
| 107 | 1.6.23.7.2 | Install appliances |  | 1d | 2016-04-26 | 2016-04-26 | 96 | 2016-04-26 | 2016-04-26 | 1d | 1d | 0d | start no earlier than 2016-04-26 |  |
| 108 | 1.6.23.7.3 | Flooring and appliances complete | milestone | 0d | 2016-04-26 | 2016-04-26 | 106, 107 | 2016-04-26 | 2016-04-26 |  | 1d |  |  |  |

| ID | WBS | Task | Type | Duration | Start | Finish | Predecessors | Baseline start | Baseline finish | Baseline duration | Total slack | Free slack | Constraint | Resources | Work |
| --- | --- | --- | --- | --- | --- | --- | --- | --- | --- | --- | --- | --- | --- | --- | --- |
| 109 | 1.6.24 | **Grounds Work** |  | 2d | 2016-04-18 | 2016-04-19 |  | 2016-04-18 | 2016-04-19 | 2d | -20d | 0d |  |  |  |
| 110 | 1.6.24.1 | Concrete covering on foundation |  | 2d | 2016-04-18 | 2016-04-19 | 62 | 2016-04-18 | 2016-04-19 | 2d | -62d | 0d | start no earlier than 2016-04-18 | Concrete |  |
| 111 | 1.6.25 | **Final Acceptance** |  | 12d | 2016-04-28 | 2016-05-11 |  | 2016-04-28 | 2016-05-11 | 12d |  |  |  |  | 8h |
| 112 | 1.6.25.1 | Complete finish inspection for certificate of occupancy |  | 1d | 2016-04-28 | 2016-04-28 | 108, 110 | 2016-04-28 | 2016-04-28 | 1d | 11d | 0d |  | Inspector | 8h |
| 113 | 1.6.25.2 | Cleanup for occupancy |  | 1d | 2016-04-29 | 2016-04-29 | 112 | 2016-04-29 | 2016-04-29 | 1d | 117d | 0d | start no earlier than 2016-04-28 |  |  |
| 114 | 1.6.25.3 | Perform final walk-through inspection |  | 1d | 2016-04-30 | 2016-04-30 | 113 | 2016-04-30 | 2016-04-30 | 1d | 117d |  | start no earlier than 2016-04-29 |  |  |
| 115 | 1.6.25.4 | Complete punch list items |  | 1d | 2016-04-29 | 2016-04-29 | 112 | 2016-04-29 | 2016-04-29 | 1d | 118d |  | start no earlier than 2016-04-29 |  |  |
| 116 | 2 | **Documentation and Presentation** |  | 34d | 2016-03-22 | 2016-04-29 |  |  |  |  |  |  |  |  |  |
| 117 | 2.1 | Finish Presentation |  | 30d | 2016-03-22 | 2016-04-25 |  |  |  |  | 3d |  | start no earlier than 2016-03-22 |  |  |
| 118 | 2.2 | Present to faculty |  | 1d | 2016-04-29 | 2016-04-29 | 117 |  |  |  | 0d |  | start no earlier than 2016-04-29 |  |  |
| 119 | 2.3 | Presentation complete | milestone | 0d | 2016-04-29 | 2016-04-29 | 118 |  |  |  | 0d |  |  |  |  |
